# GD-07 - gevel metselen+plat dak

Schedule from MS Project, 2003-01-12 to 2003-02-02, status date 2003-01-08.
BAM Nelissen Van Egteren

## Calendars

- ALLEEN WERKDAGEN: Mon-Fri 08:30-12:30, 13:00-17:00; Sat-Sun off. Exceptions (off unless hours are given): 2003-01-11 to 2003-01-12 08:30-12:30, 13:00-17:00, 2003-01-18 to 2003-01-19 08:30-12:30, 13:00-17:00, 2003-01-25 to 2003-01-26 08:30-12:30, 13:00-17:00, 2003-02-01 to 2003-02-02 08:30-12:30, 13:00-17:00.

## Schedule

| ID | WBS | Task | Type | Duration | Start | Finish | Predecessors | Total slack |
| --- | --- | --- | --- | --- | --- | --- | --- | --- |
| 1 | 1 | **GEVEL/DAK FASE** |  | 22d | 2003-01-12 | 2003-02-02 |  | 0d |
| 2 | 1.1 | beg.grond kozijnen+profielen |  | 3d | 2003-01-12 | 2003-01-14 |  | 0d |
| 3 | 1.2 | beg.grond metselen 1e slag |  | 5d | 2003-01-14 | 2003-01-18 | 2SS+2d | 0d |
| 4 | 1.3 | schraagsteiger opbouwen |  | 2d | 2003-01-18 | 2003-01-19 | 3SS+4d | 0d |
| 5 | 1.4 | beg.grond metselen 2e slag |  | 5d | 2003-01-19 | 2003-01-23 | 4SS+1d | 0d |
| 6 | 1.5 | dak boeiboord-constructie |  | 5d | 2003-01-22 | 2003-01-26 | 5SS+3d | 0d |
| 7 | 1.6 | gevel glas in kozijnen zetten |  | 3d | 2003-01-27 | 2003-01-29 | 6SS+5d | 4d |
| 8 | 1.7 | dakbalklaag+ravelingen |  | 4d | 2003-01-22 | 2003-01-25 | 6SS | 0d |
| 9 | 1.8 | dakplaten leggen |  | 4d | 2003-01-24 | 2003-01-27 | 8SS+2d | 0d |
| 10 | 1.9 | dakdoorvoeren+lichtkoepels |  | 4d | 2003-01-26 | 2003-01-29 | 9SS+2d | 0d |
| 11 | 1.10 | dak isolatie aanbrengen |  | 4d | 2003-01-28 | 2003-01-31 | 10SS+2d | 0d |
| 12 | 1.11 | dakbedekking aanbrengen |  | 4d | 2003-01-30 | 2003-02-02 | 11SS+2d | 0d |
| 13 | 1.12 | start afbouw fase | milestone | 0d | 2003-02-02 | 2003-02-02 | 12SS+4d | 0d |
